# Kurzfilmprojekt

How a schedule from MS Project changed from version to version. A marks actual dates.

## Version 1 (saved 2007-03-24, file Kurzfilmprojekt 13a.mpp)

| ID | WBS | Task | Duration | Start | Finish | Predecessors | Total float | Constraint |
| --- | --- | --- | --- | --- | --- | --- | --- | --- |
| 1 | 1 | **Produktionsvorbereitung** | 65.25d | 2008-01-07 | 2008-04-07 |  | -5d |  |
| 2 |  | Drehbuch überarbeiten | 1w | 2008-01-07 | 2008-01-11 |  | -5d |  |
| 3 |  | Drehbuch in Teilaufgaben zerlegen | 1.05w | 2008-01-14 | 2008-01-21 | 2 | -5.25d |  |
| 4 |  | Produktionsablauf festlegen | 1.04mo | 2008-01-21 | 2008-02-21 | 3 | -5.25d |  |
| 5 |  | Produktionsablauf überwachen | 1.2w | 2008-02-21 | 2008-02-29 | 4 | -5.25d |  |
| 6 |  | Drehorte erkunden | 2w | 2008-02-29 | 2008-03-14 | 5 | -5.25d |  |
| 7 |  | Drehorte auswählen | 1.05w | 2008-03-14 | 2008-03-21 | 6 | -5.25d |  |
| 8 |  | Vorsprechen abhalten | 1.05w | 2008-03-21 | 2008-03-28 | 7 | -5.25d |  |
| 9 |  | Dreherlaubnis beschaffen | 1w | 2008-03-28 | 2008-04-04 | 8 | -5.25d |  |
| 10 |  | Kameraausrüstung reservieren | 3d | 2008-04-02 | 2008-04-07 | 9FS-5% | -5.25d |  |
| 11 |  | Tonausrüstung reservieren | 3d | 2008-04-02 | 2008-04-07 | 10SS | -5.25d |  |
| 12 |  | Produktionsvorbereitung abschließen | 0d | 2008-04-07 | 2008-04-07 | 11 | -5.25d |  |
| 13 | 1.12 | **Terminplanungsmeeting** | 45.25d | 2008-01-14 | 2008-03-17 |  | 9.35d |  |
| 14 |  | Terminplanungsmeeting 1 | 2h | 2008-01-14 | 2008-01-14 |  | 52.35d | start no earlier than 2008-01-14 |
| 15 |  | Terminplanungsmeeting 2 | 2h | 2008-01-21 | 2008-01-21 |  | 47.35d | start no earlier than 2008-01-21 |
| 16 |  | Terminplanungsmeeting 3 | 2h | 2008-01-28 | 2008-01-28 |  | 42.35d | start no earlier than 2008-01-28 |
| 17 |  | Terminplanungsmeeting 4 | 2h | 2008-02-04 | 2008-02-04 |  | 37.35d | start no earlier than 2008-02-04 |
| 18 |  | Terminplanungsmeeting 5 | 2h | 2008-02-11 | 2008-02-11 |  | 32.35d | start no earlier than 2008-02-11 |
| 19 |  | Terminplanungsmeeting 6 | 2h | 2008-02-18 | 2008-02-18 |  | 27.35d | start no earlier than 2008-02-18 |
| 20 |  | Terminplanungsmeeting 7 | 2h | 2008-02-25 | 2008-02-25 |  | 22.35d | start no earlier than 2008-02-25 |
| 21 |  | Terminplanungsmeeting 8 | 2h | 2008-03-03 | 2008-03-03 |  | 17.35d | start no earlier than 2008-03-03 |
| 22 |  | Terminplanungsmeeting 9 | 2h | 2008-03-10 | 2008-03-10 |  | 12.35d | start no earlier than 2008-03-10 |
| 23 |  | Terminplanungsmeeting 10 | 2h | 2008-03-17 | 2008-03-17 |  | 7.35d | start no earlier than 2008-03-17 |
| 24 | 2 | **Produktion** | 52.07d | 2008-04-07 | 2008-06-18 | 1 | 0d |  |
| 25 | 2.1 | **Szene 7** | 5.4d | 2008-04-07 | 2008-04-14 |  | 0.35d |  |
| 26 |  | Szene 7 einrichten | 1.2d | 2008-04-07 | 2008-04-08 |  | 0.35d |  |
| 27 |  | Szene 7 proben | 8h | 2008-04-08 | 2008-04-09 | 26 | 0.35d |  |
| 28 |  | Szene 7 drehen | 8h | 2008-04-09 | 2008-04-10 | 27 | 0.35d |  |
| 29 |  | Szene 7 Ergebnisse prüfen | 1.2d | 2008-04-10 | 2008-04-11 | 28 | 0.35d |  |
| 30 |  | Szene 7 Tagesproduktion weiterverarbeiten | 1d | 2008-04-11 | 2008-04-14 | 29 | 0.35d |  |
| 31 | 2.2 | **Szene 3** | 4d | 2008-04-14 | 2008-04-18 | 25 | 0.35d |  |
| 32 |  | Szene 3 einrichten | 1d | 2008-04-14 | 2008-04-15 |  | 0.35d | start no earlier than 2008-03-31 |
| 33 |  | Szene 3 proben | 1d | 2008-04-15 | 2008-04-16 | 32 | 0.35d |  |
| 34 |  | Szene 3 drehen | 8h | 2008-04-16 | 2008-04-17 | 33 | 0.35d |  |
| 35 |  | Szene 3 Ergebnisse prüfen | 1d | 2008-04-17 | 2008-04-18 | 34 | 0.35d |  |
| 36 |  | Szene 3 Tagesproduktion weiterverarbeiten | 1d | 2008-04-17 | 2008-04-18 | 34 | 0.35d |  |
| 37 | 2.3 | **Szene 1** | 6d | 2008-04-18 | 2008-04-28 | 31 | 0.35d |  |
| 38 |  | Szene 1 einrichten | 3d | 2008-04-18 | 2008-04-23 |  | 0.35d |  |
| 39 |  | Szene 1 proben | 1d | 2008-04-23 | 2008-04-24 | 38 | 0.35d |  |
| 40 |  | Szene 1 drehen | 8h | 2008-04-24 | 2008-04-25 | 39 | 0.35d |  |
| 41 |  | Szene 1 Ergebnisse prüfen | 1d | 2008-04-25 | 2008-04-28 | 40 | 0.35d |  |
| 42 |  | Szene 1 Tagesproduktion weiterverarbeiten | 1d | 2008-04-25 | 2008-04-28 | 40 | 0.35d |  |
| 43 | 2.4 | **Szene 2** | 3.85d | 2008-04-28 | 2008-05-02 | 37 | 0d |  |
| 44 |  | Szene 2 einrichten | 1d | 2008-04-28 | 2008-04-29 |  | 0.35d |  |
| 45 |  | Szene 2 proben | 8h | 2008-04-29 | 2008-04-30 | 44 | 0.35d |  |
| 46 |  | Szene 2 drehen | 4h | 2008-04-30 | 2008-04-30 | 45 | 0.25d |  |
| 47 |  | Szene 2 Ergebnisse prüfen | 0.5d | 2008-05-01 | 2008-05-01 | 46 | 0d |  |
| 48 |  | Szene 2 Tagesproduktion weiterverarbeiten | 1d | 2008-05-01 | 2008-05-02 | 47 | 0d |  |
| 49 | 2.5 | **Szene 5** | 5.5d | 2008-05-02 | 2008-05-09 | 43 | 0d |  |
| 50 |  | Szene 5 einrichten | 2.5d | 2008-05-02 | 2008-05-06 |  | 0d |  |
| 51 |  | Szene 5 proben | 1d | 2008-05-07 | 2008-05-07 | 50 | 0d |  |
| 52 |  | Szene 5 drehen | 8h | 2008-05-08 | 2008-05-08 | 51 | 0d |  |
| 53 |  | Szene 5 Ergebnisse prüfen | 1d | 2008-05-09 | 2008-05-09 | 52 | 0d |  |
| 54 |  | Szene 5 Tagesproduktion weiterverarbeiten | 1d | 2008-05-09 | 2008-05-09 | 52 | 0d |  |
| 55 | 2.6 | **Szene 6** | 13.57d | 2008-05-12 | 2008-05-29 | 49 | 0d |  |
| 56 |  | Szene 6 einrichten | 6d | 2008-05-12 | 2008-05-19 |  | 0d |  |
| 57 |  | Szene 6 proben | 2d | 2008-05-20 | 2008-05-21 | 56 | 0d |  |
| 58 |  | Szene 6 drehen | 12.54h | 2008-05-22 | 2008-05-23 | 57 | 0d |  |
| 59 |  | Szene 6 Ergebnisse prüfen | 3d | 2008-05-23 | 2008-05-28 | 58 | 0d |  |
| 60 |  | Szene 6 Tagesproduktion weiterverarbeiten | 1d | 2008-05-28 | 2008-05-29 | 59 | 0d |  |
| 61 | 2.7 | **Szene 8** | 9d | 2008-05-29 | 2008-06-11 | 55 | 0d |  |
| 62 |  | Szene 8 einrichten | 3d | 2008-05-29 | 2008-06-03 |  | 0d |  |
| 63 |  | Szene 8 proben | 2.5d | 2008-06-03 | 2008-06-06 | 62 | 0d |  |
| 64 |  | Szene 8 drehen | 8h | 2008-06-06 | 2008-06-09 | 63 | 0d |  |
| 65 |  | Szene 8 Ergebnisse prüfen | 1.5d | 2008-06-09 | 2008-06-10 | 64 | 0d |  |
| 66 |  | Szene 8 Tagesproduktion weiterverarbeiten | 1d | 2008-06-10 | 2008-06-11 | 65 | 0d |  |
| 67 | 2.8 | **Szene 4** | 4.75d | 2008-06-11 | 2008-06-18 | 61 | 0d |  |
| 68 |  | Szene 4 einrichten | 1.5d | 2008-06-11 | 2008-06-13 |  | 0d |  |
| 69 |  | Szene 4 proben | 4h | 2008-06-13 | 2008-06-13 | 68 | 0d |  |
| 70 |  | Szene 4 drehen | 2h | 2008-06-13 | 2008-06-13 | 69 | 0d |  |

| ID | WBS | Task | Duration | Start | Finish | Predecessors | Total float |
| --- | --- | --- | --- | --- | --- | --- | --- |
| 71 |  | Szene 4 Ergebnisse prüfen | 1.5d | 2008-06-13 | 2008-06-17 | 70 | 0d |
| 72 |  | Szene 4 Tagesproduktion weiterverarbeiten | 1d | 2008-06-17 | 2008-06-18 | 71 | 0d |
| 73 | 3 | **Produktionsnachbereitung** | 101.35d | 2008-06-18 | 2008-11-06 | 24 | 0d |
| 74 |  | Filmmaterial sichten | 8.5d | 2008-06-18 | 2008-06-30 |  | 0d |
| 75 |  | Sprechtext grob festlegen | 12d | 2008-06-30 | 2008-07-16 | 74 | 0d |
| 76 |  | Filmsequenzen schriftlich bearbeiten | 10d | 2008-07-16 | 2008-07-30 | 75 | 0d |
| 77 |  | Grobschnitt | 5d | 2008-07-30 | 2008-08-06 | 76 | 0d |
| 78 |  | Detailschnitt | 10d | 2008-08-06 | 2008-08-20 | 77 | 0d |
| 79 |  | Formelle Abnahmevorführung | 1d | 2008-08-20 | 2008-08-21 | 78 | 0d |
| 80 |  | Text aufnehmen | 15d | 2008-08-21 | 2008-09-11 | 79 | 0d |
| 81 |  | Vor- und Abspann fertig stellen | 1w | 2008-09-11 | 2008-09-18 | 80 | 0d |
| 82 |  | Soundtrack fertig stellen | 16d | 2008-09-18 | 2008-10-10 | 81 | 0d |
| 83 |  | Negativ ziehen | 3.25d | 2008-10-10 | 2008-10-16 | 82 | 0d |
| 84 |  | Synchronisationsmaster auf Audiokassette speichern | 12d | 2008-10-16 | 2008-11-03 | 83 | 0d |
| 85 |  | Film- und Audiomaster archivieren | 2d | 2008-11-03 | 2008-11-05 | 84 | 0d |
| 86 |  | Fertige Filme an Vertrieb ausliefern | 1d | 2008-11-05 | 2008-11-06 | 85 | 0d |

## Version 2 (saved 2007-03-24, file Kurzfilmprojekt 13c.mpp)

Last finish stays 2008-11-06. Complete tasks 0 → 20.

Changed:

| ID | Task | Start | Finish | Complete | Total float |
| --- | --- | --- | --- | --- | --- |
| 1 | **Produktionsvorbereitung** | 2008-01-07 A |  | 0% → 99% | -5d → 0.35d |
| 2 | Drehbuch überarbeiten | 2008-01-07 A | 2008-01-11 A | 0% → 100% | -5d → none |
| 3 | Drehbuch in Teilaufgaben zerlegen | 2008-01-14 A | 2008-01-21 A | 0% → 100% | -5.25d → none |
| 4 | Produktionsablauf festlegen | 2008-01-21 A | 2008-02-21 A | 0% → 100% | -5.25d → none |
| 5 | Produktionsablauf überwachen | 2008-02-21 A | 2008-02-29 A | 0% → 100% | -5.25d → none |
| 6 | Drehorte erkunden | 2008-02-29 A | 2008-03-14 A | 0% → 100% | -5.25d → none |
| 7 | Drehorte auswählen | 2008-03-14 A | 2008-03-21 A | 0% → 100% | -5.25d → none |
| 8 | Vorsprechen abhalten | 2008-03-21 A | 2008-03-28 A | 0% → 100% | -5.25d → none |
| 9 | Dreherlaubnis beschaffen | 2008-03-28 A | 2008-04-04 A | 0% → 100% | -5.25d → none |
| 10 | Kameraausrüstung reservieren | 2008-04-02 A | 2008-04-07 A | 0% → 100% | -5.25d → none |
| 11 | Tonausrüstung reservieren | 2008-04-02 A | 2008-04-07 A | 0% → 100% | -5.25d → none |
| 13 | **Terminplanungsmeeting** | 2008-01-14 A | 2008-03-17 A | 0% → 100% | 9.35d → none |
| 14 | Terminplanungsmeeting 1 | 2008-01-14 A | 2008-01-14 A | 0% → 100% | 52.35d → none |
| 15 | Terminplanungsmeeting 2 | 2008-01-21 A | 2008-01-21 A | 0% → 100% | 47.35d → none |
| 16 | Terminplanungsmeeting 3 | 2008-01-28 A | 2008-01-28 A | 0% → 100% | 42.35d → none |
| 17 | Terminplanungsmeeting 4 | 2008-02-04 A | 2008-02-04 A | 0% → 100% | 37.35d → none |
| 18 | Terminplanungsmeeting 5 | 2008-02-11 A | 2008-02-11 A | 0% → 100% | 32.35d → none |
| 19 | Terminplanungsmeeting 6 | 2008-02-18 A | 2008-02-18 A | 0% → 100% | 27.35d → none |
| 20 | Terminplanungsmeeting 7 | 2008-02-25 A | 2008-02-25 A | 0% → 100% | 22.35d → none |
| 21 | Terminplanungsmeeting 8 | 2008-03-03 A | 2008-03-03 A | 0% → 100% | 17.35d → none |
| 22 | Terminplanungsmeeting 9 | 2008-03-10 A | 2008-03-10 A | 0% → 100% | 12.35d → none |
| 23 | Terminplanungsmeeting 10 | 2008-03-17 A | 2008-03-17 A | 0% → 100% | 7.35d → none |

## Version 3 (saved 2007-03-24, file Kurzfilmprojekt 13b.mpp)

Last finish stays 2008-11-06. Complete tasks 20 → 1.

Changed:

| ID | Task | Start | Finish | Complete | Total float |
| --- | --- | --- | --- | --- | --- |
| 1 | **Produktionsvorbereitung** |  |  | 99% → 7% | 0.35d → -5.25d |
| 3 | Drehbuch in Teilaufgaben zerlegen | 2008-01-14 A → 2008-01-14 | 2008-01-21 A → 2008-01-21 | 100% → 0% | none → -0.45d |
| 4 | Produktionsablauf festlegen | 2008-01-21 A → 2008-01-21 | 2008-02-21 A → 2008-02-21 | 100% → 0% | none → -0.45d |
| 5 | Produktionsablauf überwachen | 2008-02-21 A → 2008-02-21 | 2008-02-29 A → 2008-02-29 | 100% → 0% | none → -5.25d |
| 6 | Drehorte erkunden | 2008-02-29 A → 2008-02-29 | 2008-03-14 A → 2008-03-14 | 100% → 0% | none → -5.25d |
| 7 | Drehorte auswählen | 2008-03-14 A → 2008-03-14 | 2008-03-21 A → 2008-03-21 | 100% → 0% | none → -5.25d |
| 8 | Vorsprechen abhalten | 2008-03-21 A → 2008-03-21 | 2008-03-28 A → 2008-03-28 | 100% → 0% | none → -5.25d |
| 9 | Dreherlaubnis beschaffen | 2008-03-28 A → 2008-03-28 | 2008-04-04 A → 2008-04-04 | 100% → 0% | none → -5.25d |
| 10 | Kameraausrüstung reservieren | 2008-04-02 A → 2008-04-02 | 2008-04-07 A → 2008-04-07 | 100% → 0% | none → -5.25d |
| 11 | Tonausrüstung reservieren | 2008-04-02 A → 2008-04-02 | 2008-04-07 A → 2008-04-07 | 100% → 0% | none → -5.25d |
| 13 | **Terminplanungsmeeting** | 2008-01-14 A → 2008-01-14 | 2008-03-17 A → 2008-03-17 | 100% → 0% | none → 9.35d |
| 14 | Terminplanungsmeeting 1 | 2008-01-14 A → 2008-01-14 | 2008-01-14 A → 2008-01-14 | 100% → 0% | none → 52.35d |
| 15 | Terminplanungsmeeting 2 | 2008-01-21 A → 2008-01-21 | 2008-01-21 A → 2008-01-21 | 100% → 0% | none → 47.35d |
| 16 | Terminplanungsmeeting 3 | 2008-01-28 A → 2008-01-28 | 2008-01-28 A → 2008-01-28 | 100% → 0% | none → 42.35d |
| 17 | Terminplanungsmeeting 4 | 2008-02-04 A → 2008-02-04 | 2008-02-04 A → 2008-02-04 | 100% → 0% | none → 37.35d |
| 18 | Terminplanungsmeeting 5 | 2008-02-11 A → 2008-02-11 | 2008-02-11 A → 2008-02-11 | 100% → 0% | none → 32.35d |
| 19 | Terminplanungsmeeting 6 | 2008-02-18 A → 2008-02-18 | 2008-02-18 A → 2008-02-18 | 100% → 0% | none → 27.35d |
| 20 | Terminplanungsmeeting 7 | 2008-02-25 A → 2008-02-25 | 2008-02-25 A → 2008-02-25 | 100% → 0% | none → 22.35d |
| 21 | Terminplanungsmeeting 8 | 2008-03-03 A → 2008-03-03 | 2008-03-03 A → 2008-03-03 | 100% → 0% | none → 17.35d |
| 22 | Terminplanungsmeeting 9 | 2008-03-10 A → 2008-03-10 | 2008-03-10 A → 2008-03-10 | 100% → 0% | none → 12.35d |
| 23 | Terminplanungsmeeting 10 | 2008-03-17 A → 2008-03-17 | 2008-03-17 A → 2008-03-17 | 100% → 0% | none → 7.35d |

## Version 4 (saved 2007-03-24, file Kurzfilmprojekt 13d.mpp)

Last finish 2008-11-06 → 2008-11-07 (+1d). Complete tasks 1 → 29.

Changed:

| ID | Task | Start | Finish | Duration | Complete | Total float | Other |
| --- | --- | --- | --- | --- | --- | --- | --- |
| 1 | **Produktionsvorbereitung** |  |  |  | 7% → 99% | -5.25d → 0d |  |
| 3 | Drehbuch in Teilaufgaben zerlegen | 2008-01-14 A | 2008-01-21 A |  | 0% → 100% | -0.45d → none |  |
| 4 | Produktionsablauf festlegen | 2008-01-21 A | 2008-02-21 A |  | 0% → 100% | -0.45d → none |  |
| 5 | Produktionsablauf überwachen | 2008-02-21 A | 2008-02-29 A |  | 0% → 100% | -5.25d → none |  |
| 6 | Drehorte erkunden | 2008-02-29 A | 2008-03-14 A |  | 0% → 100% | -5.25d → none |  |
| 7 | Drehorte auswählen | 2008-03-14 A | 2008-03-21 A |  | 0% → 100% | -5.25d → none |  |
| 8 | Vorsprechen abhalten | 2008-03-21 A | 2008-03-28 A |  | 0% → 100% | -5.25d → none |  |
| 9 | Dreherlaubnis beschaffen | 2008-03-28 A | 2008-04-04 A |  | 0% → 100% | -5.25d → none |  |
| 10 | Kameraausrüstung reservieren | 2008-04-02 A | 2008-04-07 A |  | 0% → 100% | -5.25d → none |  |
| 11 | Tonausrüstung reservieren | 2008-04-02 A | 2008-04-07 A |  | 0% → 100% | -5.25d → none |  |
| 13 | **Terminplanungsmeeting** | 2008-01-14 A | 2008-03-17 A |  | 0% → 100% | 9.35d → none |  |
| 14 | Terminplanungsmeeting 1 | 2008-01-14 A | 2008-01-14 A |  | 0% → 100% | 52.35d → none |  |
| 15 | Terminplanungsmeeting 2 | 2008-01-21 A | 2008-01-21 A |  | 0% → 100% | 47.35d → none |  |
| 16 | Terminplanungsmeeting 3 | 2008-01-28 A | 2008-01-28 A |  | 0% → 100% | 42.35d → none |  |
| 17 | Terminplanungsmeeting 4 | 2008-02-04 A | 2008-02-04 A |  | 0% → 100% | 37.35d → none |  |
| 18 | Terminplanungsmeeting 5 | 2008-02-11 A | 2008-02-11 A |  | 0% → 100% | 32.35d → none |  |
| 19 | Terminplanungsmeeting 6 | 2008-02-18 A | 2008-02-18 A |  | 0% → 100% | 27.35d → none |  |
| 20 | Terminplanungsmeeting 7 | 2008-02-25 A | 2008-02-25 A |  | 0% → 100% | 22.35d → none |  |
| 21 | Terminplanungsmeeting 8 | 2008-03-03 A | 2008-03-03 A |  | 0% → 100% | 17.35d → none |  |
| 22 | Terminplanungsmeeting 9 | 2008-03-10 A | 2008-03-10 A |  | 0% → 100% | 12.35d → none |  |
| 23 | Terminplanungsmeeting 10 | 2008-03-17 A | 2008-03-17 A |  | 0% → 100% | 7.35d → none |  |
| 24 | **Produktion** | 2008-04-07 A | 2008-06-18 → 2008-06-19 (+1d) | 52.07d → 53.07d | 0% → 21% |  |  |
| 25 | **Szene 7** | 2008-04-07 A | 2008-04-14 → 2008-04-15 (+1d) | 5.4d → 6.7d | 0% → 85% | 0.35d → 46.37d |  |
| 26 | Szene 7 einrichten | 2008-04-07 A | 2008-04-08 → 2008-04-09 A (+1d) | 1.2d → 1.95d | 0% → 100% | 0.35d → none |  |
| 27 | Szene 7 proben | 2008-04-08 → 2008-04-09 A (+1d) | 2008-04-09 → 2008-04-10 A (+1d) | 8h → 12.4h | 0% → 100% | 0.35d → none | resources Stefan Meier; Michael Braun; Paul Born [50%]; Josef Mattes; Susanne Brenner; Jan Miskowski → Stefan Meier; Michael Braun; Paul Born [46.9%]; Josef Mattes [133.3%]; Susanne Brenner; Jan Miskowski [116.7%] |
| 28 | Szene 7 drehen | 2008-04-09 → 2008-04-10 A (+1d) | 2008-04-10 → 2008-04-11 A (+1d) |  | 0% → 100% | 0.35d → none |  |
| 29 | Szene 7 Ergebnisse prüfen | 2008-04-10 → 2008-04-11 A (+1d) | 2008-04-11 → 2008-04-14 A (+3d) |  | 0% → 100% | 0.35d → none |  |
| 30 | Szene 7 Tagesproduktion weiterverarbeiten | 2008-04-11 → 2008-04-14 (+3d) | 2008-04-14 → 2008-04-15 (+1d) |  |  | 0.35d → 46.37d |  |
| 31 | **Szene 3** | 2008-04-14 → 2008-04-15 A (+1d) | 2008-04-18 → 2008-04-21 A (+3d) |  | 0% → 100% | 0.35d → none |  |
| 32 | Szene 3 einrichten | 2008-04-14 → 2008-04-15 A (+1d) | 2008-04-15 → 2008-04-16 A (+1d) |  | 0% → 100% | 0.35d → none |  |
| 33 | Szene 3 proben | 2008-04-15 → 2008-04-16 A (+1d) | 2008-04-16 → 2008-04-17 A (+1d) |  | 0% → 100% | 0.35d → none |  |
| 34 | Szene 3 drehen | 2008-04-16 → 2008-04-17 A (+1d) | 2008-04-17 → 2008-04-18 A (+1d) |  | 0% → 100% | 0.35d → none |  |
| 35 | Szene 3 Ergebnisse prüfen | 2008-04-17 → 2008-04-18 A (+1d) | 2008-04-18 → 2008-04-21 A (+3d) |  | 0% → 100% | 0.35d → none |  |
| 36 | Szene 3 Tagesproduktion weiterverarbeiten | 2008-04-17 → 2008-04-18 A (+1d) | 2008-04-18 → 2008-04-21 A (+3d) |  | 0% → 100% | 0.35d → none |  |
| 37 | **Szene 1** | 2008-04-18 → 2008-04-21 A (+3d) | 2008-04-28 → 2008-04-29 (+1d) |  | 0% → 15% | 0.35d → 0.05d |  |
| 38 | Szene 1 einrichten | 2008-04-18 → 2008-04-21 A (+3d) | 2008-04-23 → 2008-04-24 (+1d) |  | 0% → 35% | 0.35d → 0.05d |  |
| 39 | Szene 1 proben | 2008-04-23 → 2008-04-24 (+1d) | 2008-04-24 → 2008-04-25 (+1d) |  |  | 0.35d → 0.05d |  |
| 40 | Szene 1 drehen | 2008-04-24 → 2008-04-25 (+1d) | 2008-04-25 → 2008-04-28 (+3d) |  |  | 0.35d → 0.05d |  |
| 41 | Szene 1 Ergebnisse prüfen | 2008-04-25 → 2008-04-28 (+3d) | 2008-04-28 → 2008-04-29 (+1d) |  |  | 0.35d → 0.05d |  |
| 42 | Szene 1 Tagesproduktion weiterverarbeiten | 2008-04-25 → 2008-04-28 (+3d) | 2008-04-28 → 2008-04-29 (+1d) |  |  | 0.35d → 0.05d |  |
| 43 | **Szene 2** | 2008-04-28 → 2008-04-29 (+1d) | 2008-05-02 → 2008-05-05 (+3d) | 3.85d → 3.55d |  |  |  |
| 44 | Szene 2 einrichten | 2008-04-28 → 2008-04-29 (+1d) | 2008-04-29 → 2008-04-30 (+1d) |  |  | 0.35d → 0.05d |  |
| 45 | Szene 2 proben | 2008-04-29 → 2008-04-30 (+1d) | 2008-04-30 → 2008-05-01 (+1d) |  |  | 0.35d → 0.05d |  |
| 46 | Szene 2 drehen | 2008-04-30 → 2008-05-01 (+1d) | 2008-04-30 → 2008-05-01 (+1d) |  |  |  |  |
| 47 | Szene 2 Ergebnisse prüfen | 2008-05-01 → 2008-05-02 (+1d) | 2008-05-01 → 2008-05-02 (+1d) |  |  |  |  |
| 48 | Szene 2 Tagesproduktion weiterverarbeiten | 2008-05-01 → 2008-05-02 (+1d) | 2008-05-02 → 2008-05-05 (+3d) |  |  |  |  |
| 49 | **Szene 5** | 2008-05-02 → 2008-05-05 (+3d) | 2008-05-09 → 2008-05-12 (+3d) |  |  |  |  |
| 50 | Szene 5 einrichten | 2008-05-02 → 2008-05-05 (+3d) | 2008-05-06 → 2008-05-07 (+1d) |  |  |  |  |
| 51 | Szene 5 proben | 2008-05-07 → 2008-05-08 (+1d) | 2008-05-07 → 2008-05-08 (+1d) |  |  |  |  |
| 52 | Szene 5 drehen | 2008-05-08 → 2008-05-09 (+1d) | 2008-05-08 → 2008-05-09 (+1d) |  |  |  |  |
| 53 | Szene 5 Ergebnisse prüfen | 2008-05-09 → 2008-05-12 (+3d) | 2008-05-09 → 2008-05-12 (+3d) |  |  |  |  |
| 54 | Szene 5 Tagesproduktion weiterverarbeiten | 2008-05-09 → 2008-05-12 (+3d) | 2008-05-09 → 2008-05-12 (+3d) |  |  |  |  |
| 55 | **Szene 6** | 2008-05-12 → 2008-05-13 (+1d) | 2008-05-29 → 2008-05-30 (+1d) |  |  |  |  |
| 56 | Szene 6 einrichten | 2008-05-12 → 2008-05-13 (+1d) | 2008-05-19 → 2008-05-20 (+1d) |  |  |  |  |
| 57 | Szene 6 proben | 2008-05-20 → 2008-05-21 (+1d) | 2008-05-21 → 2008-05-22 (+1d) |  |  |  |  |
| 58 | Szene 6 drehen | 2008-05-22 → 2008-05-23 (+1d) | 2008-05-23 → 2008-05-26 (+3d) |  |  |  |  |
| 59 | Szene 6 Ergebnisse prüfen | 2008-05-23 → 2008-05-26 (+3d) | 2008-05-28 → 2008-05-29 (+1d) |  |  |  |  |
| 60 | Szene 6 Tagesproduktion weiterverarbeiten | 2008-05-28 → 2008-05-29 (+1d) | 2008-05-29 → 2008-05-30 (+1d) |  |  |  |  |
| 61 | **Szene 8** | 2008-05-29 → 2008-05-30 (+1d) | 2008-06-11 → 2008-06-12 (+1d) |  |  |  |  |
| 62 | Szene 8 einrichten | 2008-05-29 → 2008-05-30 (+1d) | 2008-06-03 → 2008-06-04 (+1d) |  |  |  |  |
| 63 | Szene 8 proben | 2008-06-03 → 2008-06-04 (+1d) | 2008-06-06 → 2008-06-09 (+3d) |  |  |  |  |
| 64 | Szene 8 drehen | 2008-06-06 → 2008-06-09 (+3d) | 2008-06-09 → 2008-06-10 (+1d) |  |  |  |  |
| 65 | Szene 8 Ergebnisse prüfen | 2008-06-09 → 2008-06-10 (+1d) | 2008-06-10 → 2008-06-11 (+1d) |  |  |  |  |
| 66 | Szene 8 Tagesproduktion weiterverarbeiten | 2008-06-10 → 2008-06-11 (+1d) | 2008-06-11 → 2008-06-12 (+1d) |  |  |  |  |
| 67 | **Szene 4** | 2008-06-11 → 2008-06-12 (+1d) | 2008-06-18 → 2008-06-19 (+1d) |  |  |  |  |
| 68 | Szene 4 einrichten | 2008-06-11 → 2008-06-12 (+1d) | 2008-06-13 → 2008-06-16 (+3d) |  |  |  |  |
| 69 | Szene 4 proben | 2008-06-13 → 2008-06-16 (+3d) | 2008-06-13 → 2008-06-16 (+3d) |  |  |  |  |
| 70 | Szene 4 drehen | 2008-06-13 → 2008-06-16 (+3d) | 2008-06-13 → 2008-06-16 (+3d) |  |  |  |  |
| 71 | Szene 4 Ergebnisse prüfen | 2008-06-13 → 2008-06-16 (+3d) | 2008-06-17 → 2008-06-18 (+1d) |  |  |  |  |
| 72 | Szene 4 Tagesproduktion weiterverarbeiten | 2008-06-17 → 2008-06-18 (+1d) | 2008-06-18 → 2008-06-19 (+1d) |  |  |  |  |

| ID | Task | Start | Finish |
| --- | --- | --- | --- |
| 73 | **Produktionsnachbereitung** | 2008-06-18 → 2008-06-19 (+1d) | 2008-11-06 → 2008-11-07 (+1d) |
| 74 | Filmmaterial sichten | 2008-06-18 → 2008-06-19 (+1d) | 2008-06-30 → 2008-07-01 (+1d) |
| 75 | Sprechtext grob festlegen | 2008-06-30 → 2008-07-01 (+1d) | 2008-07-16 → 2008-07-17 (+1d) |
| 76 | Filmsequenzen schriftlich bearbeiten | 2008-07-16 → 2008-07-17 (+1d) | 2008-07-30 → 2008-07-31 (+1d) |
| 77 | Grobschnitt | 2008-07-30 → 2008-07-31 (+1d) | 2008-08-06 → 2008-08-07 (+1d) |
| 78 | Detailschnitt | 2008-08-06 → 2008-08-07 (+1d) | 2008-08-20 → 2008-08-21 (+1d) |
| 79 | Formelle Abnahmevorführung | 2008-08-20 → 2008-08-21 (+1d) | 2008-08-21 → 2008-08-22 (+1d) |
| 80 | Text aufnehmen | 2008-08-21 → 2008-08-22 (+1d) | 2008-09-11 → 2008-09-12 (+1d) |
| 81 | Vor- und Abspann fertig stellen | 2008-09-11 → 2008-09-12 (+1d) | 2008-09-18 → 2008-09-19 (+1d) |
| 82 | Soundtrack fertig stellen | 2008-09-18 → 2008-09-19 (+1d) | 2008-10-10 → 2008-10-13 (+3d) |
| 83 | Negativ ziehen | 2008-10-10 → 2008-10-13 (+3d) | 2008-10-16 → 2008-10-17 (+1d) |
| 84 | Synchronisationsmaster auf Audiokassette speichern | 2008-10-16 → 2008-10-17 (+1d) | 2008-11-03 → 2008-11-04 (+1d) |
| 85 | Film- und Audiomaster archivieren | 2008-11-03 → 2008-11-04 (+1d) | 2008-11-05 → 2008-11-06 (+1d) |
| 86 | Fertige Filme an Vertrieb ausliefern | 2008-11-05 → 2008-11-06 (+1d) | 2008-11-06 → 2008-11-07 (+1d) |
